# DISEÑO DE UN PROTOTIPO DE UN SISTEMA DE APROVECHAMIENTO DE ENERGÍA FOTOVOLTAICA PARA EL ABASTECIMIENTO ENERGETICO A DISPOSITIVOS MÓVILES, EN LA UNIVERSIDAD EL BOSQUE, SEDE BOGOTÁ

Schedule from MS Project, 2020-03-10 to 2020-06-22, status date 2020-06-27, costs in $, A marks actual dates.

## Calendars

- Estándar: Mon-Fri 09:00-13:00, 15:00-19:00; Sat-Sun off. Exceptions (off unless hours are given): 2020-03-15 09:00-13:00, 15:00-19:00.

## Resources

| Resource | Rate |
| --- | --- |
| JEFERSON MURILLO | 55000 |
| TECNICO 1 | 20000 |
| TECNICO 2 | 20000 |
| DAYANA HERRERA | 60000 |
| insumos | 404200 |
| Herramientas | 2740000 |
| Materiales y Otros | 1560000 |
| reserva de contingencia | 3672050 |

## Schedule

| ID | WBS | Task | Type | Duration | Start | Finish | Predecessors | Complete | Baseline start | Baseline finish | Baseline duration | Constraint | Resources | Work | Actual work | Cost | Baseline cost | Actual cost | Programado |
| --- | --- | --- | --- | --- | --- | --- | --- | --- | --- | --- | --- | --- | --- | --- | --- | --- | --- | --- | --- |
| 1 | 1 | **VIABILIDAD Y PERCEPCIÓN** |  | 12d | 2020-03-10 A | 2020-03-24 A |  | 100% | 2020-03-10 | 2020-03-24 | 12d |  |  | 96h | 96h | 1,920,000 | 1,920,000 | 1,920,000 | 100% |
| 2 | 1.1 | **Identificación de datos** |  | 6d | 2020-03-10 A | 2020-03-16 A |  | 100% | 2020-03-10 | 2020-03-16 | 6d |  |  | 48h | 48h | 960,000 | 960,000 | 960,000 | 100% |
| 3 | 1.1.1 | Realizar la encuesta a 25 estudiantes de la Universidad El Bosque con la herramienta de google formularios con un maximo de 6 preguntas que evaluen los aspectos mas importantes de uso del dispositivo movil . |  | 6d | 2020-03-10 A | 2020-03-16 A |  | 100% | 2020-03-10 | 2020-03-16 | 6d |  | TECNICO 1 | 48h | 48h | 960,000 | 960,000 | 960,000 |  |
| 4 | 1.2 | **Modelado de datos** |  | 6d | 2020-03-17 A | 2020-03-24 A |  | 100% | 2020-03-17 | 2020-03-24 | 6d |  |  | 48h | 48h | 960,000 | 960,000 | 960,000 | 100% |
| 5 | 1.2.1 | Analisis de datos obtenidos de la plataforma de google con una conclusion detallada de lo evaluado. |  | 6d | 2020-03-17 A | 2020-03-24 A | 3 | 100% | 2020-03-17 | 2020-03-24 | 6d |  | TECNICO 2 | 48h | 48h | 960,000 | 960,000 | 960,000 |  |
| 6 | 1.3 | Analisis de datos de la viabilidad y percepción ambiental finalizada | milestone | 0d | 2020-03-24 A | 2020-03-24 A | 5 | 100% | 2020-03-24 | 2020-03-24 | 0d | finish no earlier than 2020-03-16 | DAYANA HERRERA |  |  |  |  |  | 100% |
| 7 | 2 | **POTENCIAL ENERGÉTICO** |  | 19d | 2020-03-25 A | 2020-04-20 A |  | 100% | 2020-03-25 | 2020-04-20 | 19d |  |  | 152h | 152h | 8,360,000 | 8,360,000 | 8,360,000 | 58% |
| 8 | 2.1 | **Esquema Energético** |  | 11d | 2020-03-25 A | 2020-04-08 A |  | 100% | 2020-03-25 | 2020-04-08 | 11d |  |  | 88h | 88h | 4,840,000 | 4,840,000 | 4,840,000 | 100% |
| 9 | 2.1.1 | Investigar los parámetros de radiación solar en la ciudad de Bogotá en bases de datos de radiación solar basada en libros, tesis de maestría y revisión bibliográfica. |  | 11d | 2020-03-25 A | 2020-04-08 A | 5 | 100% | 2020-03-25 | 2020-04-08 | 11d |  | JEFERSON MURILLO | 88h | 88h | 4,840,000 | 4,840,000 | 4,840,000 | 100% |
| 10 | 2.2 | **Arquitectura preliminar** |  | 8d | 2020-04-09 A | 2020-04-20 A |  | 100% | 2020-04-09 | 2020-04-20 | 8d |  |  | 64h | 64h | 3,520,000 | 3,520,000 | 3,520,000 | 0% |
| 11 | 2.2.1 | Selección de diseño guía y materiales para cosntrucción. |  | 8d | 2020-04-09 A | 2020-04-20 A | 9 | 100% | 2020-04-09 | 2020-04-20 | 8d |  | JEFERSON MURILLO | 64h | 64h | 3,520,000 | 3,520,000 | 3,520,000 | 0% |
| 12 | 2.3 | Investigacion del esquema fotovoltaico y selección de diseño finalizado | milestone | 0d | 2020-04-20 A | 2020-04-20 A | 11 | 100% | 2020-04-20 | 2020-04-20 | 0d | finish no earlier than 2020-04-10 | DAYANA HERRERA |  |  |  |  |  | 0% |
| 13 | 3 | **PARAMETROS FUNCIONALES** |  | 22d | 2020-04-21 A | 2020-05-20 A |  | 100% | 2020-04-21 | 2020-05-19 | 21d |  |  | 160h | 160h | 7,120,000 | 5,800,000 | 7,120,000 | 0% |
| 14 | 3.1 | **Planos de Diseño** |  | 6d | 2020-04-21 A | 2020-04-28 A |  | 100% | 2020-04-21 | 2020-04-28 | 6d |  |  | 48h | 48h | 960,000 | 960,000 | 960,000 | 0% |
| 15 | 3.1.1 | Construcción del plano, teniendo en cuenta las investigaciones preliminares. |  | 6d | 2020-04-21 A | 2020-04-28 A | 11 | 100% | 2020-04-21 | 2020-04-28 | 6d |  | TECNICO 1 | 48h | 48h | 960,000 | 960,000 | 960,000 | 0% |
| 16 | 3.2 | **Requerimientos funcionales** |  | 9d | 2020-04-29 A | 2020-05-11 A |  | 100% | 2020-04-29 | 2020-05-08 | 8d |  |  | 64h | 64h | 3,520,000 | 2,200,000 | 3,520,000 | 0% |
| 17 | 3.2.1 | Realizar un checklist con el cumplimiento de los requisitos suministrados por los interesados para llevar una trazabilidad |  | 8d | 2020-04-29 A | 2020-05-11 A | 15 | 100% | 2020-04-29 | 2020-05-08 | 5d |  | JEFERSON MURILLO | 64h | 64h | 3,520,000 | 2,200,000 | 3,520,000 | 0% |
| 18 | 3.3 | **Proveedores y Adquisiciones** |  | 7d | 2020-05-12 A | 2020-05-20 A |  | 100% | 2020-05-11 | 2020-05-19 | 7d |  |  | 48h | 48h | 2,640,000 | 2,640,000 | 2,640,000 | 0% |
| 19 | 3.3.1 | Selección de un proveedor donde sus características sean económicas y materiales de calidad |  | 6d | 2020-05-12 A | 2020-05-20 A | 17 | 100% | 2020-05-11 | 2020-05-19 | 6d |  | JEFERSON MURILLO | 48h | 48h | 2,640,000 | 2,640,000 | 2,640,000 | 0% |
| 20 | 3.4 | Planos y checklist de cumplimiento de requerimientos junto con la selección del proveedor finalizada | milestone | 0d | 2020-05-20 A | 2020-05-20 A | 19 | 100% | 2020-05-19 | 2020-05-19 | 0d | finish no earlier than 2020-05-05 | DAYANA HERRERA |  |  |  |  |  | 0% |
| 21 | 4 | **DISEÑO UNIFICADO** |  | 16d | 2020-06-01 A | 2020-06-22 A |  | 100% | 2020-06-01 | 2020-06-22 | 16d |  |  | 328h | 328h | 9,640,000 | 9,640,000 | 9,640,000 | 0% |
| 22 | 4.1 | **Integración del prototipo** |  | 11d | 2020-06-01 A | 2020-06-15 A |  | 100% | 2020-06-01 | 2020-06-15 | 11d |  |  | 264h | 264h | 8,360,000 | 8,360,000 | 8,360,000 | 0% |
| 23 | 4.1.1 | Compra y montaje del prototipo teniendo en cuenta el plano suministrado y los requerimientos de los interesados |  | 11d | 2020-06-01 A | 2020-06-15 A | 19FS+4d | 100% | 2020-06-01 | 2020-06-15 | 11d | start no earlier than 2020-06-01 | JEFERSON MURILLO; TECNICO 1; TECNICO 2 | 264h | 264h | 8,360,000 | 8,360,000 | 8,360,000 | 0% |
| 24 | 4.2 | **Manual funcional** |  | 2d | 2020-06-16 A | 2020-06-17 A |  | 100% | 2020-06-16 | 2020-06-17 | 2d |  |  | 16h | 16h | 320,000 | 320,000 | 320,000 | 0% |
| 25 | 4.2.1 | Digitalización del manual con diseño del prototipo donde se evidencie el mantenimiento y uso. |  | 2d | 2020-06-16 A | 2020-06-17 A | 23 | 100% | 2020-06-16 | 2020-06-17 | 2d | start no earlier than 2020-06-16 | TECNICO 2 | 16h | 16h | 320,000 | 320,000 | 320,000 | 0% |

| ID | WBS | Task | Type | Duration | Start | Finish | Predecessors | Complete | Baseline start | Baseline finish | Baseline duration | Constraint | Resources | Work | Actual work | Cost | Baseline cost | Actual cost | Programado |
| --- | --- | --- | --- | --- | --- | --- | --- | --- | --- | --- | --- | --- | --- | --- | --- | --- | --- | --- | --- |
| 26 | 4.3 | **Pruebas del sistema** |  | 3d | 2020-06-18 A | 2020-06-22 A |  | 100% | 2020-06-18 | 2020-06-22 | 3d |  |  | 48h | 48h | 960,000 | 960,000 | 960,000 | 0% |
| 27 | 4.3.1 | Realizar la prueba con varios dispositivos para garantizar que el prototipo reabastesca la energía, se deben tomar los tiempos de carga (energia inicial y final) y tipo de dispositivo. |  | 3d | 2020-06-18 A | 2020-06-22 A | 25 | 100% | 2020-06-18 | 2020-06-22 | 3d | start no earlier than 2020-06-18 | TECNICO 1; TECNICO 2 | 48h | 48h | 960,000 | 960,000 | 960,000 | 0% |
| 28 | 4.4 | Socializado el producto con sus respectivas pruebas | milestone | 0d | 2020-06-22 A | 2020-06-22 A | 27 | 100% | 2020-06-22 | 2020-06-22 | 0d | finish no earlier than 2020-06-22 | DAYANA HERRERA; JEFERSON MURILLO |  |  |  |  |  | 0% |
| 29 | 5 | **GERENCIA DEL PROYECTO** |  | 76d | 2020-03-10 A | 2020-06-22 A |  | 100% | 2020-03-10 | 2020-06-22 | 76d |  |  | 200h | 200h | 19,616,250 | 19,616,250 | 19,616,250 |  |
| 30 | 5.1 | **Inicio** |  | 12d | 2020-03-10 A | 2020-03-24 A |  | 100% | 2020-03-10 | 2020-03-24 | 12d |  |  | 32h | 32h | 1,840,000 | 1,840,000 | 1,840,000 |  |
| 31 | 5.1.1 | Project Charter |  | 3d | 2020-03-19 A | 2020-03-24 A |  | 100% | 2020-03-19 | 2020-03-24 | 3d | finish no earlier than 2020-03-12 | JEFERSON MURILLO; DAYANA HERRERA | 32h | 32h | 1,840,000 | 1,840,000 | 1,840,000 |  |
| 32 | 5.1.2 | Acta de inicio firmada y listo para comenzar | milestone | 0d | 2020-03-10 A | 2020-03-10 A |  | 100% | 2020-03-10 | 2020-03-10 | 0d |  |  |  |  |  |  |  |  |
| 33 | 5.2 | **Planeación** |  | 34d | 2020-03-10 A | 2020-04-23 A |  | 100% | 2020-03-10 | 2020-04-23 | 34d |  |  | 104h | 104h | 9,392,050 | 9,392,050 | 9,392,050 |  |
| 34 | 5.2.1 | Alcance - Tiempo - Costo - Calidad |  | 8d | 2020-03-10 A | 2020-03-18 A | 32 | 100% | 2020-03-10 | 2020-03-18 | 8d |  | JEFERSON MURILLO | 64h | 64h | 3,520,000 | 3,520,000 | 3,520,000 |  |
| 35 | 5.2.2 | Recursos RRHH - Stakeholders - Comunicaciones |  | 2d | 2020-03-19 A | 2020-03-20 A | 34 | 100% | 2020-03-19 | 2020-03-20 | 2d |  | JEFERSON MURILLO | 16h | 16h | 880,000 | 880,000 | 880,000 |  |
| 36 | 5.2.3 | Riesgos |  | 8d | 2020-03-23 A | 2020-04-01 A | 35 | 100% | 2020-03-23 | 2020-04-01 | 8d | start no earlier than 2020-03-10 | reserva de contingencia |  |  | 3,672,050 | 3,672,050 | 3,672,050 |  |
| 37 | 5.2.4 | Adquisiciones |  | 3d | 2020-04-21 A | 2020-04-23 A | 36 | 100% | 2020-04-21 | 2020-04-23 | 3d |  | JEFERSON MURILLO | 24h | 24h | 1,320,000 | 1,320,000 | 1,320,000 |  |
| 38 | 5.2.5 | Acta de cierre de planeación | milestone | 0d | 2020-04-23 A | 2020-04-23 A | 37 | 100% | 2020-04-23 | 2020-04-23 | 0d | start no earlier than 2020-04-21 | DAYANA HERRERA; JEFERSON MURILLO |  |  |  |  |  |  |
| 39 | 5.3 | **Ejecución** |  | 76d | 2020-03-10 A | 2020-06-22 A |  | 100% | 2020-03-10 | 2020-06-22 | 76d |  |  |  |  | 4,704,200 | 4,704,200 | 4,704,200 |  |
| 40 | 5.3.1 | Entregables |  | 76d | 2020-03-10 A | 2020-06-22 A |  | 100% | 2020-03-10 | 2020-06-22 | 76d | start no earlier than 2020-03-10 | Materiales y Otros; Herramientas; insumos |  |  | 4,704,200 | 4,704,200 | 4,704,200 |  |
| 41 | 5.4 | **Seguimiento y Control** |  | 60d | 2020-03-10 A | 2020-05-29 A |  | 100% | 2020-03-10 | 2020-05-20 | 53d |  |  | 64h | 64h | 3,680,000 | 3,680,000 | 3,680,000 |  |
| 42 | 5.4.1 | informes de sequimiento |  | 6d | 2020-03-10 A | 2020-05-21 A |  | 100% | 2020-03-10 | 2020-05-12 | 6d | start no earlier than 2020-03-10 | JEFERSON MURILLO; DAYANA HERRERA | 48h | 48h | 2,760,000 | 2,760,000 | 2,760,000 |  |
| 43 | 5.4.2 | Control de cambios |  | 2d | 2020-05-22 A | 2020-05-29 A | 42 | 100% | 2020-05-13 | 2020-05-20 | 2d | start no earlier than 2020-04-30 | DAYANA HERRERA; JEFERSON MURILLO | 16h | 16h | 920,000 | 920,000 | 920,000 |  |
| 44 | 5.5 | **Cierre** |  | 0d | 2020-06-22 A | 2020-06-22 A |  | 100% | 2020-06-22 | 2020-06-22 | 0d |  |  |  |  |  |  |  |  |
| 45 | 5.5.1 | Administrativos | milestone | 0d | 2020-06-22 A | 2020-06-22 A |  | 100% | 2020-06-22 | 2020-06-22 | 0d | start no earlier than 2020-06-22 | DAYANA HERRERA; JEFERSON MURILLO |  |  |  |  |  |  |
| 46 | 5.5.2 | Contractuales | milestone | 0d | 2020-06-22 A | 2020-06-22 A | 45 | 100% | 2020-06-22 | 2020-06-22 | 0d |  | DAYANA HERRERA; JEFERSON MURILLO |  |  |  |  |  |  |
| 47 | 5.5.3 | Acta de cierre del proyecto | milestone | 0d | 2020-06-22 A | 2020-06-22 A | 46 | 100% | 2020-06-22 | 2020-06-22 | 0d |  | DAYANA HERRERA; JEFERSON MURILLO |  |  |  |  |  |  |
